# DDR_Phase2_plan

Schedule from MS Project, 2008-10-20 to 2009-07-13, A marks actual dates.
Det Norske Veritas

## Calendars

- Standard: Mon-Fri 08:00-12:00, 13:00-17:00; Sat-Sun off. Exceptions (off unless hours are given): 2008-12-22 to 2008-12-31, 2009-04-04 to 2009-04-13.

## Schedule

| ID | WBS | Task | Duration | Start | Finish | Predecessors | Complete | Remaining | Baseline start | Baseline finish | Baseline duration | Total slack | Free slack | Constraint |
| --- | --- | --- | --- | --- | --- | --- | --- | --- | --- | --- | --- | --- | --- | --- |
| 1 | 1 | **DDR Phase II** | 177d? | 2008-10-20 A | 2009-07-13 |  | 73% | 47.7d? | 2008-10-20 | 2009-04-01 | 110d? | 0d |  |  |
| 2 | 1.1 | Project management | 126d | 2008-10-20 A | 2009-05-01 |  | 82% | 23d | 2008-10-20 | 2009-04-01 | 110d | 51d |  | start no earlier than 2008-10-20 |
| 3 | 1.2 | **Modify XML schema** | 84d | 2008-11-11 A | 2009-03-18 A |  | 100% |  | 2008-11-11 | 2009-02-13 | 61d |  |  |  |
| 4 | 1.2.1 | Agree on mandatory/optional | 5w | 2008-11-11 A | 2008-12-15 A |  | 100% |  | 2008-11-11 | 2008-12-15 | 5w |  |  | start no earlier than 2008-11-11 |
| 5 | 1.2.2 | Update XMLschema | 11w | 2009-01-01 A | 2009-03-18 A | 4 | 100% |  | 2009-01-01 | 2009-02-13 | 6.4w |  |  | start no earlier than 2009-01-01 |
| 6 | 1.3 | Annotate XML schema with SAWSDL | 8.6w | 2009-01-19 A | 2009-03-18 A |  | 100% |  | 2009-01-19 | 2009-02-13 | 4w |  |  | finish no earlier than 2009-02-13 |
| 7 | 1.4 | Testing of updated XML including SAWSDL annotations | 2.4w | 2009-03-19 A | 2009-04-03 | 6, 5 | 33% | 1.6w | 2009-02-16 | 2009-03-13 | 4w | 65d |  |  |
| 8 | 1.5 | Coordination with Energistics | 71d | 2008-12-11 A | 2009-03-31 |  | 92% | 6d | 2008-12-11 | 2009-03-23 | 65d | 68d |  | finish no earlier than 2009-03-31 |
| 9 | 1.6 | Update user guide | 110d? | 2008-11-11 A | 2009-05-01 |  | 78% | 24d? | 2008-11-11 | 2009-02-27 | 71d? | 51d |  | finish no earlier than 2009-02-27 |
| 10 | 1.7 | Modify error messages from PSA web services | 110d? | 2008-11-11 A | 2009-05-01 |  | 78% | 24d? | 2008-11-11 | 2009-02-27 | 71d? | 51d |  | finish no earlier than 2009-02-27 |
| 11 | 1.8 | **Drilling data to partners using LicenseWeb** | 177d | 2008-10-20 A | 2009-07-13 |  | 51% | 86.09d | 2008-10-20 | 2009-04-01 | 110d | 0d |  |  |
| 12 | 1.8.1 | Make specification | 16.8w | 2008-11-12 A | 2009-03-19 A |  | 100% |  | 2008-11-12 | 2009-02-13 | 12w |  |  | finish no earlier than 2009-02-13 |
| 13 | 1.8.2 | Build solution | 5w | 2009-05-11 | 2009-06-12 | 12 |  |  | 2009-02-16 | 2009-03-20 | 5w | 13d | 12d | start no earlier than 2009-05-11 |
| 14 | 1.8.3 | Test solution | 8d | 2009-07-01 | 2009-07-10 | 13 |  |  | 2009-03-23 | 2009-04-01 | 8d | 1d |  | start no earlier than 2009-07-01 |
| 15 | 1.8.4 | TietoEnator Project management | 177d | 2008-10-20 A | 2009-07-13 |  | 38% | 110d | 2008-10-20 | 2009-04-01 | 110d | 0d |  | start no earlier than 2008-10-20 |
